# QPS Electronics Upgrade

Schedule from MS Project, 2008-09-15 to 2009-09-09.
CERN

## Calendars

- Standard: Mon-Fri 08:00-12:00, 13:00-17:00; Sat-Sun off. Exceptions (off unless hours are given): 2008-12-22 to 2009-01-02, 2009-04-04 to 2009-04-05 08:00-12:00, 13:00-17:00, 2009-04-10, 2009-04-13, 2009-05-01, 2009-05-21, 2009-06-01.

## Resources

| Resource |
| --- |
| Vincent Froidbise |
| Reiner Denz |
| Zinur Charifoulline |
| Robert Flora |
| Knud Dahlerup |
| Arend Dinius |
| Laszlo Abel |
| Fabio Formenti |
| Contractor |
| Mathieu Favre |
| Grzegorz Seweryn |
| BE-OP |
| Alan Honma |
| to be defined |
| BE-CO |
| Joaquim Mourao |
| Kevin Priestnall |
| Noel Fournier |
| Gert-Jan Coelingh |
| Edward Novak |
| Adam Drozd |
| Arkadiusz Gorzawski |
| Boris Bellesia |
| Regis Pizot |
| LP Electronik |
| TESLA |
| INEO |
| Jean Claude Guillaume |
| Delphine Jacquet |
| Giorgio D'Angelo |
| EN-ICE |
| Alick Macpherson |
| Jens Stecker |
| IHEP Protvino Team |
| FSU support #1 |
| Francisco Josa |
| CEGELEC |
| Regis Chritin |
| Vladimir Ovchar |
| BINP team |
| MPE-CP #1 |
| MPE-CP Supervisor #1 |
| Piotr Jourkiewicz |
| MPE-CP Supervisor #2 |
| MPE-CP Supervisor #3 |
| MPE-CP #2 |
| MPE-CP #3 |
| MPE-CP #4 |
| MPE-CP #5 |
| MPE-CP #6 |
| Person #1 |
| Person #2 |
| Person #3 |
| Person #4 |
| Herve Milcent |
| Odd Oyvin Andreassen |
| Raymond Brun |
| Adriaan Rijllart |
| Javier Serrano |
| FSU support #3 |
| FSU support #2 |
| Rudiger Schmidt |
| Andrzej Skoczen |
| Guy Deferne |
| Bhusan Barapatre |
| Michael Ovsienko |
| Sandor Feher |
| MPE-MI #2 |
| MPE-MI #1 |
| Olivier Desebe |
| Fabienne Boisier |
| Rachel Bray |

## Schedule

| ID | WBS | Task | Type | Duration | Start | Finish | Predecessors | Total slack | Free slack | Constraint | Resources | Work | Text1 |
| --- | --- | --- | --- | --- | --- | --- | --- | --- | --- | --- | --- | --- | --- |
| 1 | 1 | **QPS Electronics Upgrade Project (release date: February 23nd, 2009)** |  | 244d? | 2008-09-15 | 2009-09-09 |  | 0d |  |  | Knud Dahlerup [10%]; Fabio Formenti [10%] | 39087.8h | QPS EUP Project |
| 2 | 1.1 | Target for full new QPS system commissioned | milestone | 0d | 2009-08-31 | 2009-08-31 |  | 7d |  | start no earlier than 2009-08-31 |  |  |  |
| 3 | 1.2 | **DQQBS detection boards R&D and procurement** |  | 198.12d | 2008-09-29 | 2009-07-21 |  | 36d |  |  | Reiner Denz [10%] | 2599.63h | QPS EUP 1 |
| 4 | 1.2.1 | **Board design** |  | 70d | 2008-09-29 | 2009-01-16 |  | 164.12d |  |  |  | 130.8h | 1.1 |
| 5 | 1.2.1.1 | prototyping and final firmware upgrade |  | 70d | 2008-09-29 | 2009-01-16 |  | 164.12d |  | finish no earlier than 2009-01-16 | Vincent Froidbise [3%]; Reiner Denz [3%] | 33.6h | 1.1.1 |
| 6 | 1.2.1.2 | characterization and performance evaluation in LHC machine |  | 45d | 2008-10-13 | 2008-12-12 |  | 179.12d |  | finish no earlier than 2008-12-12 | Reiner Denz [5%]; Knud Dahlerup [2%]; Zinur Charifoulline [15%]; Robert Flora [5%] | 97.2h | 1.1.2 |
| 7 | 1.2.2 | **Final board specifications** |  | 29.88d | 2008-12-15 | 2009-02-06 |  | 149.12d |  |  |  | 9.58h | 1.2 |
| 8 | 1.2.2.1 | board manufacturing document (h/w) |  | 9.88d | 2008-12-15 | 2009-01-12 |  | 169.12d |  | start no earlier than 2008-12-15 | Vincent Froidbise [2%] | 1.58h | 1.2.1 |
| 9 | 1.2.2.2 | board manufacturing document (s/w) |  | 25d | 2009-01-05 | 2009-02-06 |  | 149.12d |  | finish no earlier than 2009-02-06 | Reiner Denz [2%] | 4h | 1.2.2 |
| 10 | 1.2.2.3 | definition of mass test system (h/w & s/w) |  | 10d | 2009-01-26 | 2009-02-06 |  | 149.12d |  | finish no earlier than 2009-02-06 | Reiner Denz [5%] | 4h | 1.2.3 |
| 11 | 1.2.3 | **Call for tender** |  | 25d | 2009-01-05 | 2009-02-06 |  | 67.25d |  |  |  | 186.8h | 1.3 |
| 12 | 1.2.3.1 | definition of technical matters, final technical specifications |  | 5d | 2009-01-05 | 2009-01-09 |  | 67.25d | 0d | finish no earlier than 2009-01-09 | Knud Dahlerup [2%]; Arend Dinius [10%] | 4.8h | 1.3.1 |
| 13 | 1.2.3.2 | definition of commercial matters |  | 5d | 2009-01-05 | 2009-01-09 |  | 67.25d | 0d | finish no earlier than 2009-01-09 | Laszlo Abel | 40h | 1.3.2 |
| 14 | 1.2.3.3 | decision and supplier selection |  | 15d | 2009-01-12 | 2009-01-30 | 12, 13 | 67.25d | 0d | finish no earlier than 2009-01-30 | Knud Dahlerup [1%]; Laszlo Abel; Reiner Denz [2%]; Fabio Formenti [2%]; Arend Dinius [10%] | 138h | 1.3.3 |
| 15 | 1.2.3.4 | visit Contractor and placing order |  | 5d | 2009-02-02 | 2009-02-06 | 14 | 67.25d | 2d | finish no earlier than 2009-02-06 | Arend Dinius; Reiner Denz [10%] | 4h | 1.3.4 |
| 16 | 1.2.4 | **Board production** |  | 153d | 2008-10-20 | 2009-06-08 |  | 62.25d |  |  |  | 1413.91h | 1.4 |
| 17 | 1.2.4.1 | contract follow up |  | 81d | 2009-02-11 | 2009-06-08 | 15, 23FF | 66.12d |  | start no earlier than 2009-01-26 | Reiner Denz [10%]; Knud Dahlerup [2%]; Fabio Formenti [2%]; Arend Dinius [15%]; Vincent Froidbise [5%] | 220.32h | 1.4.1 |
| 18 | 1.2.4.2 | parts procurement |  | 75d | 2008-10-20 | 2009-02-13 |  | 62.25d | 0.12d | finish no earlier than 2009-02-13 | Vincent Froidbise [5%]; Contractor | 630h | 1.4.2 |
| 19 | 1.2.4.3 | preseries production |  | 20.88d | 2009-02-16 | 2009-03-16 | 18, 15 | 62.12d | 0d | start no earlier than 2009-02-16 | Vincent Froidbise [2%]; Mathieu Favre [15%] | 28.39h | 1.4.3 |
| 20 | 1.2.4.4 | CERN preseries qualification |  | 3d | 2009-03-17 | 2009-03-19 | 19, 25, 26 | 66.12d | 0d |  |  |  | 1.4.4 |
| 21 | 1.2.4.5 | tester for mass production (h/w) |  | 15d | 2009-01-26 | 2009-02-13 |  | 90.12d | 24d | finish no earlier than 2009-02-13 | Vincent Froidbise [2%]; Grzegorz Seweryn [10%] | 14.4h | 1.4.5 |
| 22 | 1.2.4.6 | tester for mass production (s/w) |  | 15d | 2009-02-09 | 2009-02-27 |  | 80.12d | 14d | finish no earlier than 2009-02-27 | Reiner Denz [2%] | 2.4h | 1.4.6 |
| 23 | 1.2.4.7 | production, test and QA |  | 54d | 2009-03-20 | 2009-06-08 | 20, 21, 22 | 66.12d | 0d | finish no earlier than 2009-06-08 | Arend Dinius [20%]; Contractor | 518.4h | 1.4.7 |
| 24 | 1.2.5 | **Board reception in QPS lab** |  | 108d | 2009-02-16 | 2009-07-21 |  | 36d |  |  |  | 700.04h | 1.5 |
| 25 | 1.2.5.1 | tester for lab check (h/w) |  | 19d | 2009-02-16 | 2009-03-13 |  | 68d | 1.88d | start no earlier than 2009-02-16 | Vincent Froidbise [5%]; Mathieu Favre [5%] | 15.2h | 1.5.1 |
| 26 | 1.2.5.2 | tester for lab check (s/w) |  | 19d | 2009-02-16 | 2009-03-13 |  | 68d | 1.88d | start no earlier than 2009-02-16 | Reiner Denz [3%] | 4.56h | 1.5.2 |
| 27 | 1.2.5.3 | board final firware definition |  | 19d | 2009-02-16 | 2009-03-13 |  | 64d | 1.88d | start no earlier than 2009-02-16 | Reiner Denz [2%] | 3.04h | 1.5.3 |
| 28 | 1.2.5.4 | board final firmware download |  | 61d | 2009-03-17 | 2009-06-12 | 27, 19 | 62.12d |  | finish no earlier than 2009-06-12 | BE-OP | 488h | 1.5.4 |
| 29 | 1.2.5.5 | acceptance test & production screening |  | 29.88d | 2009-04-17 | 2009-06-29 | 23SS+20d | 37.12d | 0d | start no earlier than 2009-02-09 | Reiner Denz [1%]; Alan Honma [15%] | 38.25h | 1.5.5 |
| 30 | 1.2.5.6 | faulty board repairs & spare provision |  | 39.88d | 2009-04-17 | 2009-07-06 | 29SS | 47.12d |  | start no earlier than 2009-03-16 | Alan Honma [10%]; Mathieu Favre [10%] | 63.81h | 1.5.6 |
| 31 | 1.2.5.7 | board identification and storage |  | 39.88d | 2009-04-17 | 2009-07-06 | 29SS | 37.12d | 1.12d | start no earlier than 2009-04-17 | Alan Honma [2%] | 6.38h | 1.5.7 |
| 32 | 1.2.5.8 | entering data into MTF |  | 10d | 2009-07-07 | 2009-07-21 | 31 | 36d |  | start no earlier than 2009-07-07 | Vincent Froidbise [1%]; to be defined | 80.8h | 1.5.8 |

| ID | WBS | Task | Duration | Start | Finish | Predecessors | Total slack | Free slack | Constraint | Resources | Work | Text1 |
| --- | --- | --- | --- | --- | --- | --- | --- | --- | --- | --- | --- | --- |
| 33 | 1.3 | **DQAMG type S Controller board R&D and procurement** | 183d | 2008-10-20 | 2009-07-20 |  | 36.12d |  |  | Reiner Denz [10%] | 2822.12h | QPS EUP 2 |
| 34 | 1.3.1 | **Board design** | 55d | 2008-10-20 | 2009-01-16 |  | 164.12d |  |  |  | 55.6h | 2.1 |
| 35 | 1.3.1.1 | prototyping and final firmware upgrade | 55d | 2008-10-20 | 2009-01-16 |  | 164.12d |  | finish no earlier than 2009-01-16 | Vincent Froidbise [3%]; Reiner Denz [2%] | 22h | 2.1.1 |
| 36 | 1.3.1.2 | characterization and performance evaluation in LHC machine | 30d | 2008-11-03 | 2008-12-12 |  | 179.12d |  | finish no earlier than 2008-12-12 | Reiner Denz [2%]; Knud Dahlerup [2%]; Zinur Charifoulline [10%] | 33.6h | 2.1.2 |
| 37 | 1.3.2 | **Final board specifications** | 29.88d | 2008-12-15 | 2009-02-06 |  | 149.12d |  |  |  | 11.1h | 2.2 |
| 38 | 1.3.2.1 | board manufacturing document (h/w) | 9.88d | 2008-12-15 | 2009-01-12 |  | 169.12d |  | finish no earlier than 2009-01-12 | Vincent Froidbise [10%] | 7.9h | 2.2.1 |
| 39 | 1.3.2.2 | board manufacturing document (s/w) | 10d | 2009-01-26 | 2009-02-06 |  | 149.12d |  | finish no earlier than 2009-02-06 | Reiner Denz [2%] | 1.6h | 2.2.2 |
| 40 | 1.3.2.3 | definition of mass test system (h/w & s/w) | 10d | 2009-01-26 | 2009-02-06 |  | 149.12d |  | finish no earlier than 2009-02-06 | Reiner Denz [2%] | 1.6h | 2.2.3 |
| 41 | 1.3.3 | **Call for tender** | 25d | 2009-01-05 | 2009-02-06 |  | 41.38d |  |  |  | 211.2h | 2.3 |
| 42 | 1.3.3.1 | definition of technical matters, final technical specifications | 5d | 2009-01-05 | 2009-01-09 |  | 41.38d | 0d | finish no earlier than 2009-01-09 | Knud Dahlerup [15%]; Arend Dinius [10%] | 10h | 2.3.1 |
| 43 | 1.3.3.2 | definition of commercial matters | 5d | 2009-01-05 | 2009-01-09 |  | 41.38d | 0d | finish no earlier than 2009-01-09 | Laszlo Abel | 40h | 2.3.2 |
| 44 | 1.3.3.3 | decision and supplier selection | 15d | 2009-01-12 | 2009-01-30 | 42, 43 | 41.38d | 0d | finish no earlier than 2009-01-30 | Knud Dahlerup [2%]; Laszlo Abel; Reiner Denz [2%]; Fabio Formenti [2%]; Arend Dinius [15%] | 145.2h | 2.3.3 |
| 45 | 1.3.3.4 | visit Contractor and placing order | 5d | 2009-02-02 | 2009-02-06 | 44 | 41.38d | 1d | finish no earlier than 2009-02-06 | Arend Dinius [20%]; Reiner Denz [20%] | 16h | 2.3.4 |
| 46 | 1.3.4 | **Board production** | 153d | 2008-10-20 | 2009-06-08 |  | 36.38d |  |  |  | 1449.43h | 2.4 |
| 47 | 1.3.4.1 | contract follow up | 82d | 2009-02-10 | 2009-06-08 | 45, 53FF | 66.12d |  | start no earlier than 2009-02-02 | Reiner Denz [10%]; Knud Dahlerup [2%]; Fabio Formenti [2%]; Arend Dinius [20%]; Vincent Froidbise [5%] | 255.84h | 2.4.1 |
| 48 | 1.3.4.2 | parts procurement | 75d | 2008-10-20 | 2009-02-13 |  | 36.38d | 0.12d | finish no earlier than 2009-02-13 | Vincent Froidbise [5%]; Contractor | 630h | 2.4.2 |
| 49 | 1.3.4.3 | preseries production | 20.88d | 2009-02-16 | 2009-03-16 | 48, 45 | 36.25d | 0d | finish no earlier than 2009-03-16 | Vincent Froidbise [2%]; Alan Honma [15%] | 28.39h | 2.4.3 |
| 50 | 1.3.4.4 | CERN preseries qualification | 3d | 2009-03-17 | 2009-03-19 | 49, 55, 56 | 36.25d | 0d | start no earlier than 2009-03-17 |  |  | 2.4.4 |
| 51 | 1.3.4.5 | tester for mass production (h/w) | 15d | 2009-01-26 | 2009-02-13 |  | 144.12d |  | finish no earlier than 2009-02-13 | Vincent Froidbise [2%]; Grzegorz Seweryn [10%] | 14.4h | 2.4.5 |
| 52 | 1.3.4.6 | tester for mass production (s/w) | 15d | 2009-02-09 | 2009-02-27 |  | 134.12d |  | finish no earlier than 2009-02-27 | Reiner Denz [2%] | 2.4h | 2.4.6 |
| 53 | 1.3.4.7 | production, test and QA | 54d | 2009-03-20 | 2009-06-08 | 50 | 36.25d | 0d | start no earlier than 2009-03-20 | Arend Dinius [20%]; Contractor | 518.4h | 2.4.7 |
| 54 | 1.3.5 | **Board reception in QPS lab** | 107.88d | 2009-02-16 | 2009-07-20 |  | 36.12d |  |  |  | 948.39h | 2.5 |
| 55 | 1.3.5.1 | tester for lab check (h/w) | 20d | 2009-02-16 | 2009-03-16 |  | 37.12d | 0.88d | start no earlier than 2009-02-16 | Vincent Froidbise [5%]; Mathieu Favre [5%] | 16h | 2.5.1 |
| 56 | 1.3.5.2 | tester for lab check (s/w) | 20d | 2009-02-16 | 2009-03-16 |  | 37.12d | 0.88d | start no earlier than 2009-02-16 | Reiner Denz [3%] | 4.8h | 2.5.2 |
| 57 | 1.3.5.3 | board final firware definition | 20d | 2009-02-16 | 2009-03-16 |  | 63d | 0.88d | start no earlier than 2009-02-16 | Reiner Denz [2%] | 3.2h | 2.5.3 |
| 58 | 1.3.5.4 | board final firmware download | 61d | 2009-03-17 | 2009-06-12 | 57, 49 | 62.12d |  | finish no earlier than 2009-06-12 | BE-OP | 488h | 2.5.4 |
| 59 | 1.3.5.5 | acceptance test & production screening, including s/w interface to worldfip | 31.75d | 2009-04-17 | 2009-06-30 | 53SS+20d, 50 | 36.12d | 0d | start no earlier than 2009-04-17 | Reiner Denz [8.5%]; BE-CO | 275.59h | 2.5.5 |
| 60 | 1.3.5.6 | faulty board repairs & spare provision | 40d | 2009-04-17 | 2009-07-06 | 59SS | 47d |  | start no earlier than 2009-04-13 | Alan Honma [10%]; Mathieu Favre [10%] | 64h | 2.5.6 |
| 61 | 1.3.5.7 | board identification and storage | 40d | 2009-04-17 | 2009-07-06 | 59SS | 36.12d | 0d | start no earlier than 2009-04-14 | Alan Honma [5%] | 16h | 2.5.7 |
| 62 | 1.3.5.8 | entering data into MTF | 10d | 2009-07-07 | 2009-07-20 | 61 | 36.12d |  | start no earlier than 2009-07-06 | Vincent Froidbise [1%]; to be defined | 80.8h | 2.5.8 |

| ID | WBS | Task | Duration | Start | Finish | Predecessors | Total slack | Free slack | Constraint | Resources | Work | Text1 |
| --- | --- | --- | --- | --- | --- | --- | --- | --- | --- | --- | --- | --- |
| 63 | 1.4 | **DQLPU type S Crate including motherboard and connector board R&D and procurement** | 177d | 2008-11-17 | 2009-08-07 |  | 22.12d |  |  | Joaquim Mourao [5%]; Arend Dinius [5%]; Fabio Formenti [5%] | 1604.15h | QPS EUP 3 |
| 64 | 1.4.1 | **Crate design** | 50d | 2008-11-17 | 2009-02-06 |  | 149.12d |  |  |  | 212h | 3.1 |
| 65 | 1.4.1.1 | definition of mechanics for prototype | 50d | 2008-11-17 | 2009-02-06 |  | 149.12d |  | finish no earlier than 2009-02-06 | Joaquim Mourao [20%]; Mathieu Favre [10%] | 120h | 3.1.1 |
| 66 | 1.4.1.2 | electrical definition of motherboard and connectors for prototype | 50d | 2008-11-17 | 2009-02-06 |  | 149.12d |  | finish no earlier than 2009-02-06 | Vincent Froidbise [15%]; Mathieu Favre [2%] | 68h | 3.1.2 |
| 67 | 1.4.1.3 | electrical definition of Burndy connector PCB | 25d | 2009-01-05 | 2009-02-06 |  | 149.12d |  | finish no earlier than 2009-02-06 | Arend Dinius [10%]; Mathieu Favre [2%] | 24h | 3.1.3 |
| 68 | 1.4.2 | Final crate specifications | 21d | 2009-02-06 | 2009-03-06 |  | 47.12d | 0d | finish no earlier than 2009-03-06 | Joaquim Mourao [20%]; Vincent Froidbise [10%]; Arend Dinius [10%] | 67.2h | 3.2 |
| 69 | 1.4.3 | **Call for tender** | 20d | 2009-03-09 | 2009-04-03 |  | 47.12d |  |  |  | 118h | 3.3 |
| 70 | 1.4.3.1 | definition of technical matters, final technical specifications | 5d | 2009-03-09 | 2009-03-13 | 68 | 47.12d | 0d | finish no earlier than 2009-02-13 | Knud Dahlerup [20%]; Joaquim Mourao [20%]; Fabio Formenti [5%]; Arend Dinius [20%] | 26h | 3.3.1 |
| 71 | 1.4.3.2 | definition of commercial matters | 5d | 2009-03-09 | 2009-03-13 | 68 | 47.12d | 0d | finish no earlier than 2009-02-13 | Laszlo Abel | 40h | 3.3.2 |
| 72 | 1.4.3.3 | visit Contractor, decision and supplier selection | 5d | 2009-03-30 | 2009-04-03 | 70FS+10d, 71FS+10d | 47.12d | 0d | start no earlier than 2009-03-16 | Joaquim Mourao [5%]; Arend Dinius [20%]; Laszlo Abel; Fabio Formenti [5%] | 52h | 3.3.3 |
| 73 | 1.4.4 | **Crate production** | 126.88d | 2009-01-05 | 2009-07-03 |  | 47.12d |  |  |  | 575.75h | 3.4 |
| 74 | 1.4.4.1 | contract follow up | 57d | 2009-04-09 | 2009-07-03 | 78FF, 72 | 47.12d |  | finish no earlier than 2009-06-05 | Joaquim Mourao [10%]; Fabio Formenti [10%] | 91.2h | 3.4.1 |
| 75 | 1.4.4.2 | parts procurement | 39.88d | 2009-01-05 | 2009-02-27 |  | 91.12d | 44d | start no earlier than 2009-01-05 | Vincent Froidbise [5%]; Arend Dinius [20%] | 79.75h | 3.4.2 |
| 76 | 1.4.4.3 | qualification of the preseries production | 3d | 2009-05-04 | 2009-05-06 | 75, 72FS+19d | 47.12d | 0d | finish no earlier than 2009-04-10 | Joaquim Mourao [15%]; Fabio Formenti [10%]; Arend Dinius [20%] | 10.8h | 3.4.3 |
| 77 | 1.4.4.4 | programming of mass production tester | 5d | 2009-03-02 | 2009-03-09 |  | 89d | 41.88d | start no earlier than 2009-03-02 | Kevin Priestnall [25%] | 10h | 3.4.4 |
| 78 | 1.4.4.5 | production, test and QA | 40d | 2009-05-07 | 2009-07-03 | 76, 77 | 47.12d | 0d | finish no earlier than 2009-05-22 | Arend Dinius [20%]; Contractor | 384h | 3.4.5 |
| 79 | 1.4.5 | **Crate reception in QPS lab** | 106.88d | 2009-03-09 | 2009-08-07 |  | 22.12d |  |  |  | 428.8h | 3.5 |
| 80 | 1.4.5.1 | programming of tester for lab | 5d | 2009-03-09 | 2009-03-16 |  | 78d | 55.88d | start no earlier than 2009-03-09 | Kevin Priestnall [30%] | 12h | 3.5.1 |
| 81 | 1.4.5.2 | acceptance test & production screening | 30d | 2009-06-05 | 2009-07-24 | 80, 78SS+19d | 22.12d | 0d | start no earlier than 2009-05-11 | Joaquim Mourao [25%]; Alan Honma [20%] | 108h | 3.5.2 |
| 82 | 1.4.5.3 | HV insulation test | 30d | 2009-06-05 | 2009-07-24 | 81SS | 32.12d |  | start no earlier than 2009-06-01 | Mathieu Favre [5%]; Grzegorz Seweryn [40%] | 108h | 3.5.3 |
| 83 | 1.4.5.4 | faulty units repairs & spare provision | 30d | 2009-06-05 | 2009-07-24 | 81SS | 32.25d |  | start no earlier than 2009-06-01 | Alan Honma [10%]; Mathieu Favre [20%] | 72h | 3.5.4 |
| 84 | 1.4.5.5 | units identification and storage | 30d | 2009-06-05 | 2009-07-24 | 81SS | 22.12d | 0d | start no earlier than 2009-06-01 | Alan Honma [20%] | 48h | 3.5.5 |
| 85 | 1.4.5.6 | entering data into MTF | 10d | 2009-07-27 | 2009-08-07 | 84 | 22.12d |  | start no earlier than 2009-07-13 | Joaquim Mourao [1%]; to be defined | 80.8h | 3.5.6 |
| 86 | 1.5 | **DQLPUS Power Supply R&D and procurement** | 157.12d | 2008-11-17 | 2009-07-13 |  | 42d |  |  | Vincent Froidbise [5%]; Knud Dahlerup [5%]; Arend Dinius [5%] | 1686.55h | QPS EUP 4 |
| 87 | 1.5.1 | **Power module design** | 50d | 2008-11-17 | 2009-02-06 |  | 149.12d |  |  |  | 300h | 4.1 |
| 88 | 1.5.1.1 | prototyping | 50d | 2008-11-17 | 2009-02-06 |  | 149.12d |  | finish no earlier than 2009-02-06 | Vincent Froidbise [25%]; Grzegorz Seweryn [50%] | 300h | 4.1.1 |

| ID | WBS | Task | Duration | Start | Finish | Predecessors | Total slack | Free slack | Constraint | Resources | Work | Text1 |
| --- | --- | --- | --- | --- | --- | --- | --- | --- | --- | --- | --- | --- |
| 89 | 1.5.2 | **Final power module specifications** | 25d | 2009-01-12 | 2009-02-13 |  | 144.12d |  |  |  | 14h | 4.2 |
| 90 | 1.5.2.1 | module manufacturing document | 20d | 2009-01-12 | 2009-02-06 |  | 149.12d |  | finish no earlier than 2009-02-06 | Vincent Froidbise [5%] | 8h | 4.2.1 |
| 91 | 1.5.2.2 | definition of tester for mass production (h/w & s/w) | 25d | 2009-01-12 | 2009-02-13 |  | 144.12d |  | finish no earlier than 2009-02-13 | Vincent Froidbise [3%] | 6h | 4.2.2 |
| 92 | 1.5.3 | **Call for tender** | 20d | 2009-02-02 | 2009-02-27 |  | 59.12d |  |  |  | 106.8h | 4.3 |
| 93 | 1.5.3.1 | definition of technical matters, final technical specifications | 10d | 2009-02-02 | 2009-02-13 |  | 59.12d | 0d | finish no earlier than 2009-02-13 | Knud Dahlerup [20%] | 16h | 4.3.1 |
| 94 | 1.5.3.2 | definition of commercial matters | 10d | 2009-02-02 | 2009-02-13 |  | 59.12d | 0d | finish no earlier than 2009-02-13 | Laszlo Abel | 80h | 4.3.2 |
| 95 | 1.5.3.3 | decision and supplier selection | 5d | 2009-02-16 | 2009-02-20 | 93, 94 | 59.12d | 0d | finish no earlier than 2009-02-20 | Vincent Froidbise [1%]; Knud Dahlerup [1%]; Arend Dinius [15%] | 6.8h | 4.3.3 |
| 96 | 1.5.3.4 | visit Contractor and placing order | 5d | 2009-02-23 | 2009-02-27 | 95 | 59.12d | 0d | finish no earlier than 2009-02-27 | Vincent Froidbise [5%]; Knud Dahlerup [5%] | 4h | 4.3.4 |
| 97 | 1.5.4 | **Power module production** | 115d | 2009-01-05 | 2009-06-17 |  | 59.12d |  |  |  | 702.8h | 4.4 |
| 98 | 1.5.4.1 | contract follow up | 75d | 2009-03-02 | 2009-06-17 | 96, 102FF | 59.12d |  | finish no earlier than 2009-06-05 | Vincent Froidbise [10%]; Arend Dinius [25%]; Knud Dahlerup [2%] | 222h | 4.4.1 |
| 99 | 1.5.4.2 | parts procurement | 35d | 2009-01-05 | 2009-02-20 |  | 84.12d | 15d | finish no earlier than 2009-02-20 | Vincent Froidbise [15%]; Noel Fournier [12%] | 75.6h | 4.4.2 |
| 100 | 1.5.4.3 | qualification of the preseries production | 15d | 2009-03-16 | 2009-04-03 | 99 | 69.12d | 0d | finish no earlier than 2009-04-03 | Vincent Froidbise [6%] | 7.2h | 4.4.3 |
| 101 | 1.5.4.4 | tester for mass production (h/w & s/w) | 5d | 2009-02-09 | 2009-02-13 |  | 104.12d | 35d | finish no earlier than 2009-02-13 | Kevin Priestnall [25%]; Mathieu Favre [10%] | 14h | 4.4.4 |
| 102 | 1.5.4.5 | production, test and QA | 40d | 2009-04-04 | 2009-06-03 | 101, 100 | 69.12d | 0d | finish no earlier than 2009-05-22 | Arend Dinius [20%]; Contractor | 384h | 4.4.5 |
| 103 | 1.5.5 | **Power module reception in QPS lab** | 87d | 2009-03-09 | 2009-07-13 |  | 42d |  |  |  | 374.4h | 4.5 |
| 104 | 1.5.5.1 | tester for lab check (h/w & s/w) | 12d | 2009-03-09 | 2009-03-25 |  | 77d | 7.88d | start no earlier than 2009-03-09 | Kevin Priestnall [15%] | 14.4h | 4.5.1 |
| 105 | 1.5.5.2 | acceptance test & production screening | 40d | 2009-04-04 | 2009-06-03 | 102SS, 104 | 69.12d | 0d | finish no earlier than 2009-05-29 | Vincent Froidbise [10%]; Alan Honma [25%] | 112h | 4.5.2 |
| 106 | 1.5.5.3 | faulty module repairs, including spares | 50d | 2009-04-04 | 2009-06-17 | 105SS | 59.12d |  | start no earlier than 2009-03-30 | Alan Honma [10%]; Mathieu Favre [10%] | 80h | 4.5.3 |
| 107 | 1.5.5.4 | module identification and storage | 40d | 2009-04-04 | 2009-06-03 | 105SS | 49.12d | 7.12d | finish no earlier than 2009-05-29 | Alan Honma [2%] | 6.4h | 4.5.4 |
| 108 | 1.5.5.5 | entering data into MTF | 20d | 2009-06-15 | 2009-07-13 | 107 | 42d |  | start no earlier than 2009-06-15 | Vincent Froidbise [1%]; to be defined | 161.6h | 4.5.5 |
| 109 | 1.6 | **Signal cables and their connectivity** | 151.12d | 2008-10-27 | 2009-06-12 |  | 63d |  |  | Gert-Jan Coelingh [10%] | 13088.7h | QPS EUP 5 |
| 110 | 1.6.1 | **Cabling specification** | 65d | 2008-10-27 | 2009-02-06 |  | 149.12d |  |  |  | 1446h | 5.1 |
| 111 | 1.6.1.1 | cable and connector definition | 15d | 2008-10-27 | 2008-11-14 |  | 149.12d | 0d | finish no earlier than 2008-11-14 | Gert-Jan Coelingh [50%]; Edward Novak [80%]; Adam Drozd [80%]; Arkadiusz Gorzawski [70%] | 336h | 5.1.1 |
| 112 | 1.6.1.2 | installation layout and cable database insertion | 55d | 2008-10-27 | 2009-01-23 | 111SS | 159.12d | 40d | finish no earlier than 2009-01-23 | Gert-Jan Coelingh [20%]; Edward Novak [60%]; Adam Drozd [60%]; Arkadiusz Gorzawski [60%] | 880h | 5.1.2 |
| 113 | 1.6.1.3 | verification of DIC | 25d | 2009-01-05 | 2009-02-06 | 112SS | 149.12d |  | finish no earlier than 2009-02-06 | Gert-Jan Coelingh [15%]; Boris Bellesia | 230h | 5.1.3 |

| ID | WBS | Task | Type | Duration | Start | Finish | Predecessors | Total slack | Free slack | Constraint | Resources | Work | Text1 |
| --- | --- | --- | --- | --- | --- | --- | --- | --- | --- | --- | --- | --- | --- |
| 114 | 1.6.2 | **Cable construction and installation** |  | 119d | 2008-11-17 | 2009-05-15 |  | 80.12d |  |  |  | 4175.36h | 5.2 |
| 115 | 1.6.2.1 | cable and connector procurement |  | 50d | 2008-11-17 | 2009-02-06 | 111 | 149.12d | 25.12d | finish no earlier than 2009-01-30 | Jean Claude Guillaume; Regis Pizot | 800h | 5.2.1 |
| 116 | 1.6.2.2 | PCB for Harting connectors D20/D21 |  | 30d | 2009-01-12 | 2009-02-20 |  | 139.12d | 0.12d | finish no earlier than 2009-02-20 | Noel Fournier [10%]; Joaquim Mourao [5%]; LP Electronik | 276h | 5.2.2 |
| 117 | 1.6.2.3 | fixing cables to PCB Harting adapters |  | 71d | 2009-01-12 | 2009-04-21 | 116SS, 115SS | 98d |  | start no earlier than 2009-01-12 | Noel Fournier [2%]; TESLA | 579.36h | 5.2.3 |
| 118 | 1.6.2.4 | cutting, connector fixing, functional test, labelling and integrity check at INEO's |  | 76d | 2009-01-05 | 2009-04-21 | 115SS | 98d |  | start no earlier than 2009-01-05 | Jean Claude Guillaume; INEO | 1216h | 5.2.4 |
| 119 | 1.6.2.5 | Barcode labelling: database and label printing |  | 31d | 2009-02-02 | 2009-05-15 |  | 80.12d | 5d | start no earlier than 2009-02-02 | Rachel Bray | 248h | 5.2.5 |
| 120 | 1.6.2.6 | installation in tunnel and 1st verification w.r.t. cable database |  | 66d | 2009-02-09 | 2009-05-13 | 122 | 68d | 0d | start no earlier than 2009-02-09 | Jean Claude Guillaume; INEO | 1056h | 5.2.6 |
| 121 | 1.6.3 | **Cable verification** |  | 92.12d | 2009-01-12 | 2009-05-22 |  | 77d |  |  |  | 5539.2h | 5.3 |
| 122 | 1.6.3.1 | cable tester construction for INEO |  | 10d | 2009-01-12 | 2009-01-23 |  | 78.12d | 10.12d | finish no earlier than 2009-01-23 | Giorgio D'Angelo [50%]; Piotr Jourkiewicz | 120h | 5.3.1 |
| 123 | 1.6.3.2 | cable tester construction for MPE-CP |  | 10d | 2009-01-26 | 2009-02-06 |  | 77.12d | 0.12d | finish no earlier than 2009-02-06 | Giorgio D'Angelo [50%]; Piotr Jourkiewicz | 120h | 5.3.2 |
| 124 | 1.6.3.3 | cable & connector integrity verification, HI-Pot test, 2nd layout check (acceptance), barcode label glueing |  | 72d | 2009-02-09 | 2009-05-22 | 120SS, 123, 119SS | 77d | 4d | start no earlier than 2009-02-09 | Noel Fournier [35%]; MPE-CP Supervisor #1; MPE-CP Supervisor #2; MPE-CP Supervisor #3; MPE-CP #1; MPE-CP #2; MPE-CP #3; MPE-CP #4; MPE-CP #5; Fabienne Boisier [85%] | 5299.2h | 5.3.3 |
| 125 | 1.6.4 | **Noise floor measurements** |  | 66d | 2009-02-23 | 2009-05-28 |  | 73d |  |  |  | 1687.2h | 5.4 |
| 126 | 1.6.4.1 | tester preparation for bus bar segment voltage measurement (h/w & f/w) |  | 10d | 2009-02-23 | 2009-03-09 |  | 83d | 10d | start no earlier than 2009-02-23 | Knud Dahlerup [10%]; Vincent Froidbise [10%]; Reiner Denz [15%] | 28h | 5.4.1 |
| 127 | 1.6.4.2 | PC programming for testers (s/w) |  | 10d | 2009-03-02 | 2009-03-16 |  | 78d | 5d | start no earlier than 2009-03-02 | Arkadiusz Gorzawski [50%] | 40h | 5.4.2 |
| 128 | 1.6.4.3 | random noise floor detection and D20/D21 voltage tap verification |  | 46d | 2009-03-23 | 2009-05-28 | 126, 127, 124FF | 73d |  | start no earlier than 2009-03-23 | Knud Dahlerup [20%]; Noel Fournier [20%]; Person #1; Person #2; Person #3; Person #4 | 1619.2h | 5.4.3 |
| 129 | 1.6.5 | Technical documentation |  | 15d | 2009-05-20 | 2009-06-12 | 120 | 63d |  | start no earlier than 2009-05-20 | Jean Claude Guillaume | 120h | 5.5 |
| 130 | 1.7 | **Controls and interlocks signals upgrade** |  | 113.12d | 2008-11-24 | 2009-05-15 |  | 81d |  |  | Herve Milcent [10%] | 1394.5h | QPS EUP 6 |
| 131 | 1.7.1 | **List of various tasks (fully outsourced)** |  | 113.12d | 2008-11-24 | 2009-05-15 |  | 81d |  |  |  | 1304h | 6.1 |
| 132 | 1.7.1.1 | update of signal database names for the new 30k signals |  | 20d | 2009-02-02 | 2009-02-27 |  | 134.12d |  | finish no earlier than 2009-02-27 | Reiner Denz [15%]; Alick Macpherson [20%]; Odd Oyvin Andreassen [30%]; EN-ICE | 264h | 6.1.1 |
| 133 | 1.7.1.2 | update of gateway control s/w | milestone | 0d | 2009-04-30 | 2009-04-30 |  | 91d |  | start no earlier than 2009-04-30 | Herve Milcent; EN-ICE |  | 6.1.2 |
| 134 | 1.7.1.3 | purchase of worldfip components |  | 35d | 2008-11-24 | 2009-01-23 |  | 159.12d |  | finish no earlier than 2009-01-23 | Raymond Brun; BE-CO | 560h | 6.1.3 |
| 135 | 1.7.1.4 | installation and connection of repeaters |  | 25d | 2009-02-02 | 2009-03-06 |  | 129.12d |  | finish no earlier than 2009-03-06 | Raymond Brun; BE-CO | 400h | 6.1.4 |
| 136 | 1.7.1.5 | gateways reconfiguration | milestone | 0d | 2009-04-17 | 2009-04-17 |  | 100d |  | start no earlier than 2009-04-17 | Herve Milcent; EN-ICE |  | 6.1.5 |
| 137 | 1.7.1.6 | upgrade of communication protocols between QPS and gateway | milestone | 0d | 2009-04-17 | 2009-04-17 |  | 100d |  | start no earlier than 2009-04-17 | Adriaan Rijllart; EN-ICE |  | 6.1.6 |
| 138 | 1.7.1.7 | slow LHC timing introduced in bldg 281 |  | 5d | 2009-01-26 | 2009-01-30 |  | 154.12d |  | finish no earlier than 2009-01-30 | Javier Serrano; BE-CO | 80h | 6.1.7 |
| 139 | 1.7.1.8 | s/w for control room | milestone | 0d | 2009-05-15 | 2009-05-15 |  | 81d |  | start no earlier than 2009-05-15 | Herve Milcent; EN-ICE |  | 6.1.8 |

| ID | WBS | Task | Duration | Start | Finish | Predecessors | Total slack | Free slack | Constraint | Resources | Work | Text1 |
| --- | --- | --- | --- | --- | --- | --- | --- | --- | --- | --- | --- | --- |
| 140 | 1.8 | **Complete system test setup and IST in QPS lab (pre-commissioniong)** | 124.12d | 2009-03-02 | 2009-08-26 |  | 10d |  |  | Reiner Denz [10%] | 1049.3h | QPS EUP 7 |
| 141 | 1.8.1 | **Specifications** | 10d | 2009-03-02 | 2009-03-13 |  | 79.12d |  |  |  | 208h | 7.1 |
| 142 | 1.8.1.1 | full system lab test h/w | 10d | 2009-03-02 | 2009-03-13 |  | 79.12d | 0d | finish no earlier than 2009-03-13 | Vincent Froidbise [30%]; Grzegorz Seweryn | 24h | 7.1.1 |
| 143 | 1.8.1.2 | full system lab test on-line s/w | 10d | 2009-03-02 | 2009-03-13 |  | 79.12d | 0d | finish no earlier than 2009-03-13 | Alick Macpherson; BE-OP | 160h | 7.1.2 |
| 144 | 1.8.1.3 | test result database | 10d | 2009-03-02 | 2009-03-13 |  | 79.12d | 0d | finish no earlier than 2009-03-13 | Zinur Charifoulline [30%] | 24h | 7.1.3 |
| 145 | 1.8.2 | **Test setup assembly** | 10d | 2009-03-16 | 2009-03-27 |  | 79.12d |  |  |  | 28h | 7.2 |
| 146 | 1.8.2.1 | assembly and verification of testbench (h/w & s/w) | 10d | 2009-03-16 | 2009-03-27 | 142, 143 | 79.12d | 69.12d | finish no earlier than 2009-03-27 | Reiner Denz [10%]; Joaquim Mourao [20%] | 24h | 7.2.1 |
| 147 | 1.8.2.2 | installation of database | 10d | 2009-03-16 | 2009-03-27 | 144 | 79.12d | 69.12d | finish no earlier than 2009-03-27 | Zinur Charifoulline [5%] | 4h | 7.2.2 |
| 148 | 1.8.3 | **Test setup operation** | 35d | 2009-07-08 | 2009-08-26 |  | 10d |  |  |  | 714h | 7.3 |
| 149 | 1.8.3.1 | run lab test | 35d | 2009-07-08 | 2009-08-26 | 146, 147, 29SS, 59SS, 81SS, 105SS, 230SS | 10d | 0d | finish no earlier than 2009-05-29 | Reiner Denz [10%]; BE-OP | 308h | 7.3.1 |
| 150 | 1.8.3.2 | data analysis and performance | 35d | 2009-07-08 | 2009-08-26 | 149SS | 10d |  | finish no earlier than 2009-05-29 | Reiner Denz [15%]; Kevin Priestnall; Alan Honma [30%] | 406h | 7.3.2 |
| 151 | 1.9 | **Radiation tolerance tests** | 21d | 2009-03-16 | 2009-04-14 |  | 103d |  |  | Fabio Formenti [10%]; Reiner Denz [5%] | 239.2h | QPS EUP 8 |
| 152 | 1.9.1 | **Selection devices and definition of tests** | 15d | 2009-03-16 | 2009-04-04 |  | 103d |  |  |  | 138h | 8.1 |
| 153 | 1.9.1.1 | h/w definition and construction | 15d | 2009-03-16 | 2009-04-04 |  | 103d | 0d | start no earlier than 2009-03-16 | Fabio Formenti [25%]; Jens Stecker [25%]; Mathieu Favre [30%]; Noel Fournier [10%] | 108h | 8.1.1 |
| 154 | 1.9.1.2 | s/w definition and implementation | 15d | 2009-03-16 | 2009-04-04 |  | 103d | 0d | start no earlier than 2009-03-16 | Reiner Denz [15%] | 18h | 8.1.2 |
| 155 | 1.9.1.3 | test procedure definition | 15d | 2009-03-16 | 2009-04-04 |  | 103d | 0d | start no earlier than 2009-03-16 | Reiner Denz [5%]; Fabio Formenti [5%] | 12h | 8.1.3 |
| 156 | 1.9.2 | **Operation at PSI Willigen and data analysis** | 6d | 2009-04-04 | 2009-04-14 |  | 103d |  |  |  | 76h | 8.2 |
| 157 | 1.9.2.1 | operation | 1d | 2009-04-04 | 2009-04-05 | 153, 154, 155 | 103d | 0d | start no earlier than 2009-04-04 | Fabio Formenti; Jens Stecker | 16h | 8.2.1 |
| 158 | 1.9.2.2 | result analysis | 5d | 2009-04-05 | 2009-04-14 | 157 | 103d |  | finish no earlier than 2009-04-10 | Reiner Denz; Fabio Formenti [50%] | 60h | 8.2.2 |
| 159 | 1.10 | **Complete system installation and IST in LHC tunnel (electronics commissioning)** | 107.12d | 2009-04-06 | 2009-09-09 |  | 0d |  |  | Knud Dahlerup [10%] | 2453.7h | QPS EUP 9 |
| 160 | 1.10.1 | **Installation** | 107.12d | 2009-04-06 | 2009-09-09 |  | 0d |  |  |  | 1376h | 9.1 |
| 161 | 1.10.1.1 | s/w installation | 40d | 2009-04-06 | 2009-06-05 |  | 67.12d |  | finish no earlier than 2009-06-05 | Vincent Froidbise [15%] | 48h | 9.1.1 |
| 162 | 1.10.1.2 | h/w installation and connections | 40d | 2009-07-15 | 2009-09-09 | 149SS+5d | 0d |  | finish no earlier than 2009-06-19 | Noel Fournier [30%]; IHEP Protvino Team | 416h | 9.1.2 |
| 163 | 1.10.1.3 | rewiring of field bus cable, new connectors mounted | 30d | 2009-04-29 | 2009-06-12 |  | 62.12d | 52.12d | finish no earlier than 2009-06-12 | Mathieu Favre [80%]; FSU support #1; FSU support #2; FSU support #3 | 912h | 9.1.3 |

| ID | WBS | Task | Duration | Start | Finish | Predecessors | Total slack | Constraint | Resources | Work | Text1 |
| --- | --- | --- | --- | --- | --- | --- | --- | --- | --- | --- | --- |
| 164 | 1.10.2 | **IST in LHC tunnel** | 40d | 2009-07-15 | 2009-09-09 |  | 0d |  |  | 992h | 9.2 |
| 165 | 1.10.2.1 | operation from machine, functionality and performance tests, verification vs. specifications, corrective actions, EMC tests | 40d | 2009-07-15 | 2009-09-09 | 161SS, 162SS, 163SS, 149SS+5d | 0d | finish no earlier than 2009-06-26 | Reiner Denz [80%]; Fabio Formenti [80%]; Knud Dahlerup [50%] | 672h | 9.2.1 |
| 166 | 1.10.2.2 | on-line s/w and database support | 40d | 2009-07-15 | 2009-09-09 | 165SS | 0d | finish no earlier than 2009-06-26 | Herve Milcent | 320h | 9.2.2 |
| 167 | 1.11 | **Implementation of frontend s/w for specific measurement campaign** | 86.12d | 2009-02-23 | 2009-06-26 |  | 53d |  | Zinur Charifoulline [10%] | 767.3h | QPS EUP 13 |
| 168 | 1.11.1 | Automatic procedure for data treatment & storage related to snapshots | 82d | 2009-02-23 | 2009-06-19 |  | 57.12d | finish no earlier than 2009-06-19 | Zinur Charifoulline [15%]; Robert Flora [10%]; Arkadiusz Gorzawski [20%] | 295.2h | 13.1 |
| 169 | 1.11.2 | Automatic procedure for data treatment & storage related to precision measurements of BB segment resistance | 82d | 2009-02-23 | 2009-06-19 |  | 57.12d | finish no earlier than 2009-06-19 | Zinur Charifoulline [15%]; Robert Flora [10%]; Arkadiusz Gorzawski [20%] | 295.2h | 13.2 |
| 170 | 1.11.3 | s/w for inductive compensation during ramping | 54d | 2009-04-06 | 2009-06-26 |  | 53d | start no earlier than 2009-04-06 | Reiner Denz [10%]; Vincent Froidbise [15%] | 108h | 13.3 |
| 171 | 1.12 | **Infrastructure and connectivity** | 82d | 2008-12-18 | 2009-04-24 |  | 94.12d |  | Noel Fournier [10%] | 1364h | QPS EUP 14 |
| 172 | 1.12.1 | **Firewall interlock** | 52d | 2008-12-18 | 2009-03-13 |  | 124.12d |  |  | 904.4h | 14.1 |
| 173 | 1.12.1.1 | PCB | 35d | 2009-01-19 | 2009-03-06 |  | 129.12d | finish no earlier than 2009-03-06 | Noel Fournier [15%]; LP Electronik | 322h | 14.1.1 |
| 174 | 1.12.1.2 | interlock cables | 52d | 2008-12-18 | 2009-03-13 |  | 124.12d | finish no earlier than 2009-03-13 | Noel Fournier [15%]; CEGELEC | 478.4h | 14.1.2 |
| 175 | 1.12.1.3 | interlock connection box | 20d | 2009-01-19 | 2009-02-13 |  | 144.12d | finish no earlier than 2009-02-13 | Noel Fournier [10%] | 16h | 14.1.3 |
| 176 | 1.12.1.4 | PCB soldering | 10d | 2009-02-02 | 2009-02-13 |  | 144.12d | finish no earlier than 2009-02-13 | Noel Fournier [10%]; TESLA | 88h | 14.1.4 |
| 177 | 1.12.2 | **Powering cables** | 60d | 2009-02-02 | 2009-04-24 |  | 94.12d |  |  | 394h | 14.2 |
| 178 | 1.12.2.1 | procurement | 25d | 2009-02-02 | 2009-03-06 |  | 129.12d | finish no earlier than 2009-03-06 | Noel Fournier [5%] | 10h | 14.1.1 |
| 179 | 1.12.2.2 | installation | 40d | 2009-03-02 | 2009-04-24 |  | 94.12d | finish no earlier than 2009-04-24 | Mathieu Favre [20%]; IHEP Protvino Team | 384h | 14.1.2 |
| 180 | 1.13 | **Remote reset facilities** | 43d | 2009-04-24 | 2009-06-26 |  | 52.12d |  | Reiner Denz [10%] | 314.4h | QPS EUP 15 |
| 181 | 1.13.1 | **Reset modules** | 43d | 2009-04-24 | 2009-06-26 |  | 52.12d |  |  | 280h | 15.1 |
| 182 | 1.13.1.1 | Complete module manufacture | 15d | 2009-04-24 | 2009-05-15 |  | 80.12d | finish no earlier than 2009-05-15 | Mathieu Favre [5%]; Grzegorz Seweryn [15%] | 24h | 15.1.1 |
| 183 | 1.13.1.2 | Module installation and connection | 20d | 2009-05-22 | 2009-06-19 |  | 57.12d | finish no earlier than 2009-06-19 | Mathieu Favre [20%]; IHEP Protvino Team | 192h | 15.1.2 |
| 184 | 1.13.1.3 | Test and commissioning of the system | 20d | 2009-05-29 | 2009-06-26 |  | 52.12d | finish no earlier than 2009-06-26 | Reiner Denz [20%]; Robert Flora [20%] | 64h | 15.1.3 |
| 185 | 1.14 | **Hardware commissioning of new protection system** | 45d | 2009-06-29 | 2009-08-28 |  | 7.12d |  | Rudiger Schmidt [10%] | 8100h | QPS EUP 17 |
| 186 | 1.14.1 | Planning and Scheduling | 45d | 2009-06-29 | 2009-08-28 |  | 7.12d | finish no earlier than 2009-08-28 | Knud Dahlerup [90%]; Fabio Formenti [90%] | 648h | 17.1 |
| 187 | 1.14.2 | **Front 1 A.M.** | 45d | 2009-06-29 | 2009-08-28 |  | 7.12d |  |  | 1080h | 17.2 |
| 188 | 1.14.2.1 | Team Leader | 45d | 2009-06-29 | 2009-08-28 |  | 7.12d | finish no earlier than 2009-08-28 | Robert Flora | 360h | 17.2.1 |
| 189 | 1.14.2.2 | Operators | 45d | 2009-06-29 | 2009-08-28 |  | 7.12d | finish no earlier than 2009-08-28 | Kevin Priestnall; Adam Drozd | 720h | 17.2.2 |

| ID | WBS | Task | Type | Duration | Start | Finish | Predecessors | Total slack | Free slack | Constraint | Resources | Work | Text1 |
| --- | --- | --- | --- | --- | --- | --- | --- | --- | --- | --- | --- | --- | --- |
| 190 | 1.14.3 | **Front 2 A.M.** |  | 45d | 2009-06-29 | 2009-08-28 |  | 7.12d |  |  |  | 1080h | 17.3 |
| 191 | 1.14.3.1 | Team Leader |  | 45d | 2009-06-29 | 2009-08-28 |  | 7.12d |  | finish no earlier than 2009-08-28 | Andrzej Skoczen | 360h | 17.3.1 |
| 192 | 1.14.3.2 | Operators |  | 45d | 2009-06-29 | 2009-08-28 |  | 7.12d |  | finish no earlier than 2009-08-28 | Arkadiusz Gorzawski; Guy Deferne | 720h | 17.3.2 |
| 193 | 1.14.4 | **Front 1 P.M.** |  | 45d | 2009-06-29 | 2009-08-28 |  | 7.12d |  |  |  | 1080h | 17.4 |
| 194 | 1.14.4.1 | Team Leader |  | 45d | 2009-06-29 | 2009-08-28 |  | 7.12d |  | finish no earlier than 2009-08-28 | Zinur Charifoulline | 360h | 17.4.1 |
| 195 | 1.14.4.2 | Operators |  | 45d | 2009-06-29 | 2009-08-28 |  | 7.12d |  | finish no earlier than 2009-08-28 | Grzegorz Seweryn; Regis Chritin | 720h | 17.4.2 |
| 196 | 1.14.5 | **Front 2 P.M.** |  | 45d | 2009-06-29 | 2009-08-28 |  | 7.12d |  |  |  | 1080h | 17.5 |
| 197 | 1.14.5.1 | Team Leader |  | 45d | 2009-06-29 | 2009-08-28 |  | 7.12d |  | finish no earlier than 2009-08-28 | Edward Novak | 360h | 17.5.1 |
| 198 | 1.14.5.2 | Operators |  | 45d | 2009-06-29 | 2009-08-28 |  | 7.12d |  | finish no earlier than 2009-08-28 | Michael Ovsienko; Bhusan Barapatre | 720h | 17.5.2 |
| 199 | 1.14.6 | Reserve manpower for commissioning |  | 45d | 2009-06-29 | 2009-08-28 |  | 7.12d |  | finish no earlier than 2009-08-28 | Sandor Feher; Alan Honma; MPE-MI #1; MPE-MI #2 | 1440h | 17.6 |
| 200 | 1.14.7 | Linkperson to operation |  | 45d | 2009-06-29 | 2009-08-28 |  | 7.12d |  | finish no earlier than 2009-08-28 | Alick Macpherson [40%] | 144h | 17.7 |
| 201 | 1.14.8 | Field team |  | 45d | 2009-06-29 | 2009-08-28 |  | 7.12d |  | finish no earlier than 2009-08-28 | Reiner Denz [70%]; Joaquim Mourao [70%]; Vincent Froidbise [70%]; Gert-Jan Coelingh [70%]; Noel Fournier [70%]; Mathieu Favre [70%] | 1512h | 17.8 |
| 202 | 1.15 | **DQQDS Symmetric quench detector board R&D and procurement** |  | 235.88d | 2008-09-15 | 2009-08-28 |  | 8.12d |  |  | Vincent Froidbise [10%] | 1175.16h | QPS EUP 18 |
| 203 | 1.15.1 | **Board design** |  | 127d | 2008-09-15 | 2009-03-25 |  | 10.24d |  |  |  | 983.26h | 18.1 |
| 204 | 1.15.1.1 | FPGA development (ver.1) and system interfacing |  | 100d | 2008-09-15 | 2009-02-16 |  | 21.12d | 12d | start no earlier than 2008-09-15 | Jens Stecker [90%] | 720h | 18.1.1 |
| 205 | 1.15.1.2 | Digital part of DQQDS |  | 100.88d | 2008-09-15 | 2009-02-16 |  | 10.24d | 0.12d | start no earlier than 2008-09-15 | Jens Stecker [8%]; Vincent Froidbise [5%] | 104.91h | 18.1.2 |
| 206 | 1.15.1.3 | Analog input part of DQQDS |  | 100.88d | 2008-09-15 | 2009-02-16 |  | 10.24d | 0.12d | start no earlier than 2008-09-15 | Joaquim Mourao [5%] | 40.35h | 18.1.3 |
| 207 | 1.15.1.4 | Chamonix decision on Sym Protection priority | milestone | 0d | 2009-02-13 | 2009-02-13 |  | 145d |  | start no earlier than 2009-02-13 |  |  | 18.1.4 |
| 208 | 1.15.1.5 | Construction of prototypes |  | 10d | 2009-02-17 | 2009-03-03 | 205, 206 | 10.12d | 1d | start no earlier than 2009-02-17 | Mathieu Favre [10%]; Grzegorz Seweryn [10%] | 16h | 18.1.5 |
| 209 | 1.15.1.6 | Qualification of prototypes |  | 15d | 2009-03-04 | 2009-03-25 | 208, 204 | 9.12d | 1d | start no earlier than 2009-03-04 | Reiner Denz [5%]; Jens Stecker [80%] | 102h | 18.1.6 |
| 210 | 1.15.2 | **Final board specifications** |  | 28d | 2009-03-02 | 2009-04-07 |  | 19.12d |  |  |  | 3.2h | 18.2 |
| 211 | 1.15.2.1 | Final design document (h/w & f/w) |  | 10d | 2009-03-26 | 2009-04-07 | 209 | 8.12d | 0d | start no earlier than 2009-03-26 | Jens Stecker [2%]; Vincent Froidbise [2%] | 3.2h | 18.2.1 |
| 212 | 1.15.2.2 | tester for mass production (h/w) |  | 15d | 2009-03-02 | 2009-03-23 |  | 32.12d | 24d | start no earlier than 2009-03-02 |  |  | 18.2.2 |
| 213 | 1.15.2.3 | tester for mass production (s/w) |  | 15d | 2009-03-02 | 2009-03-23 |  | 32.12d | 24d | start no earlier than 2009-03-02 |  |  | 18.2.3 |

| ID | WBS | Task | Duration | Start | Finish | Predecessors | Total slack | Free slack | Constraint | Resources | Work | Text1 |
| --- | --- | --- | --- | --- | --- | --- | --- | --- | --- | --- | --- | --- |
| 214 | 1.15.3 | **Call for tender** | 11d | 2009-04-07 | 2009-04-24 |  | 8.12d |  |  |  |  | 18.3 |
| 215 | 1.15.3.1 | definition of technical matters, final technical specifications | 5d | 2009-04-07 | 2009-04-16 | 211 | 8.12d | 0d |  |  |  | 18.3.1 |
| 216 | 1.15.3.2 | definition of commercial matters | 5d | 2009-04-07 | 2009-04-16 | 211 | 8.12d | 0d |  |  |  | 18.3.2 |
| 217 | 1.15.3.3 | decision and supplier selection | 1d | 2009-04-16 | 2009-04-17 | 215, 216 | 8.12d | 0d |  |  |  | 18.3.3 |
| 218 | 1.15.3.4 | visit Contractor and placing order | 5d | 2009-04-17 | 2009-04-24 | 217 | 8.12d | 0d |  |  |  | 18.3.4 |
| 219 | 1.15.4 | **Board production** | 109d | 2009-02-23 | 2009-07-29 |  | 22.12d |  |  |  |  | 18.4 |
| 220 | 1.15.4.1 | contract follow up | 64d | 2009-04-27 | 2009-07-29 | 218, 224FF | 30d |  | start no earlier than 2009-04-20 |  |  | 18.4.1 |
| 221 | 1.15.4.2 | parts procurement | 30d | 2009-02-23 | 2009-04-04 |  | 22.12d | 14d | start no earlier than 2009-02-23 |  |  | 18.4.2 |
| 222 | 1.15.4.3 | preseries production | 25d | 2009-04-24 | 2009-06-03 | 218, 221, 212, 213 | 8.12d | 0d |  |  |  | 18.4.3 |
| 223 | 1.15.4.4 | CERN preseries qualification | 10d | 2009-06-03 | 2009-06-17 | 222 | 8.12d | 0d |  |  |  | 18.4.4 |
| 224 | 1.15.4.5 | production, test and QA | 30d | 2009-06-17 | 2009-07-29 | 223 | 8.12d | 0d |  |  |  | 18.4.5 |
| 225 | 1.15.5 | **Board reception** | 121d | 2009-03-09 | 2009-08-28 |  | 8.12d |  |  |  |  | 18.5 |
| 226 | 1.15.5.1 | tester for lab check (h/w) | 10d | 2009-03-16 | 2009-03-30 |  | 77.12d | 69d | start no earlier than 2009-03-16 |  |  | 18.5.1 |
| 227 | 1.15.5.2 | tester for lab check (s/w) | 10d | 2009-03-16 | 2009-03-30 |  | 77.12d | 69d | start no earlier than 2009-03-16 |  |  | 18.5.2 |
| 228 | 1.15.5.3 | board final firware definition | 44d | 2009-03-09 | 2009-05-08 | 204, 209SS | 55.12d | 25.12d | start no earlier than 2009-03-07 |  |  | 18.5.3 |
| 229 | 1.15.5.4 | board final firmware download | 30d | 2009-06-17 | 2009-07-29 | 222, 228, 224FF | 30d |  |  |  |  | 18.5.4 |
| 230 | 1.15.5.5 | acceptance test & production screening | 27d | 2009-07-08 | 2009-08-14 | 224SS+15d, 226, 227 | 8.12d | 0d |  |  |  | 18.5.5 |
| 231 | 1.15.5.6 | faulty board repairs & spare provision | 26.88d | 2009-07-08 | 2009-08-14 | 230SS | 18.12d |  | start no earlier than 2009-07-06 |  |  | 18.5.6 |
| 232 | 1.15.5.7 | board identification and storage | 26.88d | 2009-07-08 | 2009-08-14 | 230SS | 8.12d | 0d | start no earlier than 2009-07-06 |  |  | 18.5.7 |
| 233 | 1.15.5.8 | entering data into MTF | 10d | 2009-08-14 | 2009-08-28 | 232 | 8.12d |  |  |  |  | 18.5.8 |
| 234 | 1.16 | **DQQDE voltage to ground feeler board R&D and procurement** | 1d? | 2009-01-29 | 2009-01-29 |  | 155.12d |  |  | Joaquim Mourao [10%] | 8.72h | QPS EUP 19 |
| 235 | 1.16.1 | **Board design** | 1d? | 2009-01-29 | 2009-01-29 |  | 155.12d |  |  |  | 7.6h | 19.1 |
| 236 | 1.16.1.1 | development and system interfacing based on DQQDC | 1d? | 2009-01-29 | 2009-01-29 |  | 155.12d |  |  | Vincent Froidbise [15%]; Joaquim Mourao [15%] | 2.4h | 19.1.1 |
| 237 | 1.16.1.2 | Construction of prototypes | 1d? | 2009-01-29 | 2009-01-29 |  | 155.12d |  |  | Mathieu Favre [25%]; Grzegorz Seweryn [20%] | 3.6h | 19.1.2 |
| 238 | 1.16.1.3 | Qualification of prototypes | 1d? | 2009-01-29 | 2009-01-29 |  | 155.12d |  |  | Reiner Denz [10%]; Knud Dahlerup [10%] | 1.6h | 19.1.3 |

| ID | WBS | Task | Type | Duration | Start | Finish | Predecessors | Total slack | Free slack | Constraint | Resources | Work | Text1 |
| --- | --- | --- | --- | --- | --- | --- | --- | --- | --- | --- | --- | --- | --- |
| 239 | 1.16.2 | **Final board specifications** |  | 1d? | 2009-01-29 | 2009-01-29 |  | 155.12d |  |  |  | 0.32h | 19.2 |
| 240 | 1.16.2.1 | Final design document |  | 1d? | 2009-01-29 | 2009-01-29 |  | 155.12d |  |  | Vincent Froidbise [2%]; Joaquim Mourao [2%] | 0.32h | 19.2.1 |
| 241 | 1.17 | **Installation of already existing arc detectors in DQS (option)** |  | 0d | 2009-06-26 | 2009-06-26 |  | 53d |  |  | Knud Dahlerup |  | QPS EUP 20 |
| 242 | 1.17.1 | Preparation of the optical fibers | milestone | 0d | 2009-06-26 | 2009-06-26 |  | 53d |  | start no earlier than 2009-06-26 | Vladimir Ovchar; BINP team |  | 20.1 |
| 243 | 1.17.2 | Installation in sectors 8-1, 1-2, 3-4, 4-5 (excluded RR53), 5-6, 6-7 | milestone | 0d | 2009-06-26 | 2009-06-26 |  | 53d |  | finish no earlier than 2009-06-26 | Vladimir Ovchar; BINP team |  | 20.2 |
| 244 | 1.17.3 | Calibration of all installed detectors | milestone | 0d | 2009-06-26 | 2009-06-26 |  | 53d |  | finish no earlier than 2009-06-26 | Vladimir Ovchar; BINP team |  | 20.3 |
| 245 | 1.18 | **UPS upgrade** |  | 33d? | 2009-02-16 | 2009-04-02 |  | 111d |  |  | Knud Dahlerup [10%] | 85.9h | QPS EUP 21 |
| 246 | 1.18.1 | **Upgrade follow up** |  | 21.88d? | 2009-02-16 | 2009-03-17 |  | 122.12d |  |  | Knud Dahlerup [10%] | 17.5h | 21.1 |
| 247 | 1.18.1.1 | New layout specifications (cabling and patches) |  | 6.88d? | 2009-02-16 | 2009-02-24 |  | 122.12d | 0d | finish no earlier than 2009-02-24 |  |  | 21.1.1 |
| 248 | 1.18.1.2 | Update schematic drawings |  | 5d | 2009-02-25 | 2009-03-04 | 247 | 132d |  | start no earlier than 2009-02-25 |  |  | 21.1.2 |
| 249 | 1.18.1.3 | Revision of QPS racks |  | 15d | 2009-02-25 | 2009-03-17 | 247 | 122.12d |  | finish no earlier than 2009-03-13 |  |  | 21.1.3 |
| 250 | 1.18.1.4 | Pulling new power cables |  | 1d? | 2009-02-25 | 2009-02-26 |  | 136d |  | start no earlier than 2009-02-25 |  |  |  |
| 251 | 1.18.2 | Database implementation |  | 15d | 2009-03-12 | 2009-04-02 |  | 111d |  | start no earlier than 2009-03-12 | Joaquim Mourao [35%] | 42h | 21.2 |
| 253 | 2 | **QPS Maintenance and Operation Project (release date: February 23rd, 2009)** |  | 167d? | 2008-10-13 | 2009-06-19 |  | 57.12d |  |  | Knud Dahlerup [10%]; Fabio Formenti [10%] | 6075.6h | QPS M&O Project |
| 254 | 2.1 | **Cold Diode procurement** |  | 90d | 2009-02-11 | 2009-06-19 |  | 57.12d |  |  | Knud Dahlerup [5%]; Robert Flora [10%] | 144h | QPS M&O 10 |
| 255 | 2.1.1 | Procurement contract follow up and reception tests at warm conditions |  | 90d | 2009-02-11 | 2009-06-19 |  | 57.12d |  | finish no earlier than 2009-06-19 | Knud Dahlerup [5%]; Robert Flora | 36h | 10.1 |
| 256 | 2.2 | **Maintenance work of energy extraction facilities** |  | 92d | 2009-02-09 | 2009-06-19 |  | 57.12d |  |  | Knud Dahlerup [10%] | 801.6h | QPS M&O 11 |
| 257 | 2.2.1 | **600A EE facilities** |  | 69d | 2009-02-09 | 2009-05-15 |  | 80.12d |  |  | Gert-Jan Coelingh | 624h | 11.1 |
| 258 | 2.2.1.1 | upgrade of embedded s/w of interface card |  | 10d | 2009-05-04 | 2009-05-15 |  | 80.12d |  | finish no earlier than 2009-05-15 | Reiner Denz [2%]; Arkadiusz Gorzawski [10%] | 9.6h | 11.1.1 |
| 259 | 2.2.1.2 | replecement of switch in RR53 |  | 10d | 2009-02-09 | 2009-02-20 |  | 139.12d |  | finish no earlier than 2009-02-20 | Gert-Jan Coelingh [4%]; Edward Novak [4%] | 6.4h | 11.1.2 |
| 260 | 2.2.1.3 | modification of airflow for cooling of 600A EE racks |  | 5d | 2009-03-02 | 2009-03-06 |  | 129.12d |  | finish no earlier than 2009-03-06 | Francisco Josa | 40h | 11.1.3 |
| 261 | 2.2.1.4 | acceptance tests of 40 new switches |  | 5d | 2009-03-02 | 2009-03-06 |  | 129.12d |  | finish no earlier than 2009-03-06 | Knud Dahlerup [20%]; Gert-Jan Coelingh [20%] | 16h | 11.1.4 |
| 262 | 2.2.2 | **13kA EE facilities** |  | 82d | 2009-02-23 | 2009-06-19 |  | 57.12d |  |  |  | 104h | 11.2 |
| 263 | 2.2.2.1 | yearly maintenance of 32 4.5kA switches in sector 5-6 |  | 5d | 2009-02-23 | 2009-02-27 |  | 134.12d |  | finish no earlier than 2009-02-27 | Noel Fournier [50%]; IHEP Protvino Team [50%] | 40h | 11.2.1 |
| 264 | 2.2.2.2 | test of thermal behavior of DQRB during extraction with double time constant |  | 5d | 2009-06-15 | 2009-06-19 |  | 57.12d |  | finish no earlier than 2009-06-19 | Knud Dahlerup [80%]; Noel Fournier [80%] | 64h | 11.2.2 |

| ID | WBS | Task | Duration | Start | Finish | Total slack | Constraint | Resources | Work | Text1 |
| --- | --- | --- | --- | --- | --- | --- | --- | --- | --- | --- |
| 265 | 2.3 | **Repair work of sector 3-4** | 153d | 2008-10-13 | 2009-05-29 | 71.12d |  | Knud Dahlerup [10%] | 4814.4h | QPS M&O 12 |
| 266 | 2.3.1 | Remove all QPS equipments with potential faults | 70d | 2008-10-13 | 2009-01-30 | 154.12d | finish no earlier than 2009-01-30 | Joaquim Mourao [30%]; Mathieu Favre [30%]; Kevin Priestnall [10%]; FSU support #1 [80%]; FSU support #2 [80%]; FSU support #3 [80%] | 1736h | 12.1 |
| 267 | 2.3.2 | Cleaning of all DQLPUs and re-testing | 70d | 2008-12-01 | 2009-03-20 | 119.12d | finish no earlier than 2009-03-20 | Olivier Desebe [80%]; FSU support #1 [80%]; FSU support #2 [80%] | 1344h | 12.2 |
| 268 | 2.3.3 | Verification of the removed DQHDS units and repair when needed | 30d | 2009-01-19 | 2009-02-27 | 134.12d | finish no earlier than 2009-02-27 | Joaquim Mourao [20%]; Olivier Desebe; FSU support #1 [80%]; FSU support #2 [80%] | 432h | 12.3 |
| 269 | 2.3.4 | Reinstallation and reconnection of all QPS equipments in sector 3-4 | 50d | 2009-03-12 | 2009-05-22 | 76.12d | finish no earlier than 2009-05-22 | Joaquim Mourao [30%]; Olivier Desebe [30%]; Kevin Priestnall [20%]; FSU support #1; FSU support #2 | 1120h | 12.4 |
| 270 | 2.3.5 | Communication test from CCC | 5d | 2009-05-25 | 2009-05-29 | 71.12d | finish no earlier than 2009-05-29 | Reiner Denz [15%]; Zinur Charifoulline [35%]; Alick Macpherson | 60h | 12.5 |
| 271 | 2.4 | **Hardware recommissioning sector 3-4** | 1d? | 2009-01-29 | 2009-01-29 | 155.12d |  | Rudiger Schmidt [10%] | 88.4h | QPS M&O 16 |
| 272 | 2.4.1 | Planning and Scheduling | 1d? | 2009-01-29 | 2009-01-29 | 155.12d |  | Knud Dahlerup [15%]; Fabio Formenti [15%] | 2.4h | 16.1 |
| 273 | 2.4.2 | Detailed h/w check in sector 3-4, verification and fixing in laboratory | 1d? | 2009-01-29 | 2009-01-29 | 155.12d |  | Olivier Desebe [25%] | 2h | 16.2 |
| 274 | 2.4.3 | **Team AM** | 1d? | 2009-01-29 | 2009-01-29 | 155.12d |  |  | 24h | 16.3 |
| 275 | 2.4.3.1 | Team Leader | 1d? | 2009-01-29 | 2009-01-29 | 155.12d |  | Robert Flora | 8h | 16.3.1 |
| 276 | 2.4.3.2 | Operators | 1d? | 2009-01-29 | 2009-01-29 | 155.12d |  | Kevin Priestnall; Adam Drozd | 16h | 16.3.2 |
| 277 | 2.4.4 | **Team AM** | 1d? | 2009-01-29 | 2009-01-29 | 155.12d |  |  | 24h | 16.4 |
| 278 | 2.4.4.1 | Team Leader | 1d? | 2009-01-29 | 2009-01-29 | 155.12d |  | Zinur Charifoulline | 8h | 16.4.1 |
| 279 | 2.4.4.2 | Operators | 1d? | 2009-01-29 | 2009-01-29 | 155.12d |  | Grzegorz Seweryn; Regis Chritin | 16h | 16.4.2 |
| 280 | 2.4.5 | Linkperson to operation | 1d? | 2009-01-29 | 2009-01-29 | 155.12d |  | Alick Macpherson [20%] | 1.6h | 16.5 |
| 281 | 2.4.6 | Field team | 1d? | 2009-01-29 | 2009-01-29 | 155.12d |  | Reiner Denz [70%]; Joaquim Mourao [70%]; Vincent Froidbise [70%]; Gert-Jan Coelingh [70%]; Noel Fournier [70%]; Mathieu Favre [70%] | 33.6h | 16.6 |
